# GPNS timeline project plan

Schedule from MS Project, 2017-07-10 to 2017-09-04, costs in $.

## Calendars

- Standard: Mon-Sun 08:00-12:00, 13:00-17:00.

## Resources

| Resource | Rate |
| --- | --- |
| Sales Engineer |  |
| FTG installer 1 |  |
| Sales Rep |  |
| Hotel Rep |  |
| Hotel Accounting |  |
| Accounts Receivables |  |
| Contract & Revenue Administrator |  |
| Project Manager |  |
| Hotel Staff |  |
| Project Coordinator |  |
| TDE |  |
| Irvine Warehouse |  |
| Fed Ex |  |
| FTG installer 2 |  |
| Client Relations Manager |  |
| Sales Coordinator |  |
| FSR |  |
| Finance/Accounting |  |
| Marriott Corporate IT Dept |  |
| GPNS HSIA installer 1 | 65 |
| Room Technician 1 |  |
| Room Technician 2 |  |
| Room Technician 3 |  |
| Lead Technician |  |
| GPNS HSIA installer 2 | 65 |
| GPNS HSIA installer 3 |  |
| GPNS HSIA installer 4 |  |
| Graphics Department |  |
| HSIA installer 1 |  |
| HSIA installer 2 |  |
| SLC Warehouse |  |
| Signoff Specialist |  |

## Schedule

| ID | WBS | Task | Type | Duration | Start | Finish | Predecessors | Total slack | Free slack | Constraint | Resources | Work | Cost |
| --- | --- | --- | --- | --- | --- | --- | --- | --- | --- | --- | --- | --- | --- |
| 1 | 1 | **Project Deployment Plan** |  | 47d | 2017-07-10 08:00 | 2017-08-25 17:00 |  |  |  |  |  | 288.55h | 13,520 |
| 2 | 1.1 | Project Starts | milestone, manual | 0d | 2017-07-10 08:00 | 2017-07-10 08:00 |  |  |  |  |  |  |  |
| 3 | 1.2 | **Weekly Project Progress Calls** |  | 36d | 2017-07-24 08:00 | 2017-08-28 17:00 |  |  |  |  |  | 1.45h |  |
| 4 | 1.2.1 | Weekly Project Progress Calls 1 |  | 1h | 2017-07-31 08:00 | 2017-07-31 09:00 |  | 0d |  | start no earlier than 2017-07-31 08:00 | Hotel Staff [8%]; Project Manager [8%]; Sales Engineer [8%] | 0.24h |  |
| 5 | 1.2.2 | Weekly Project Progress Calls 2 |  | 1h | 2017-08-07 09:00 | 2017-08-07 10:00 | 4FS+7d | 0d |  | start no earlier than 2016-08-05 08:00 | Hotel Staff [8%]; Project Manager [8%]; Sales Engineer [8%] | 0.24h |  |
| 6 | 1.2.3 | Weekly Project Progress Calls 3 |  | 1h | 2017-08-14 10:00 | 2017-08-14 11:00 | 5FS+7d | 0d |  | start no earlier than 2016-08-12 08:00 | Hotel Staff [8%]; Project Manager [8%]; Sales Engineer [8%] | 0.24h |  |
| 7 | 1.2.4 | Weekly Project Progress Calls 4 |  | 1h | 2017-08-21 11:00 | 2017-08-21 12:00 | 6FS+7d | 0d |  | start no earlier than 2016-08-19 08:00 | Hotel Staff [8%]; Project Manager [8%]; Sales Engineer [8%] | 0.24h |  |
| 8 | 1.2.5 | Weekly Project Progress Calls 5 |  | 1h | 2017-08-28 13:00 | 2017-08-28 14:00 | 7FS+7d | 0d |  | start no earlier than 2016-08-26 08:00 | Hotel Staff [8%]; Project Manager [8%]; Sales Engineer [8%] | 0.24h |  |
| 9 | 1.2.6 | Weekly Project Progress Calls 6 |  | 1h | 2017-09-04 14:00 | 2017-09-04 15:00 | 8FS+7d | 0d |  | start no earlier than 2016-08-26 08:00 | Hotel Staff [8%]; Project Manager [8%]; Sales Engineer [8%] | 0.25h |  |
| 10 | 1.3 | **Planning** |  | 43d | 2017-07-10 08:00 | 2017-08-21 17:00 | 2 |  |  |  |  | 69.1h |  |
| 11 | 1.3.1 | **Kick Off Call made with Hotel** |  | 0d | 2017-07-17 08:00 | 2017-07-17 08:00 |  |  |  |  | Sales Rep; Sales Engineer; Project Manager; Hotel Staff; Project Coordinator |  |  |
| 12 | 1.3.1.1 | Contacts exchanged | milestone | 0d | 2017-07-18 17:00 | 2017-07-18 17:00 | 2SS+9d | 47.75d |  | start no earlier than 2017-07-18 08:00 | Project Manager [50%]; Hotel Staff [50%] |  |  |
| 13 | 1.3.1.2 | Installation dates are set with Hotel | milestone | 0d | 2017-07-18 17:00 | 2017-07-18 17:00 | 2SS+9d | 47.75d |  | start no earlier than 2017-06-13 08:00 | Project Manager [50%]; Hotel Staff [50%] |  |  |
| 14 | 1.3.2 | **Material procurement** |  | 35d | 2017-07-19 08:00 | 2017-08-22 17:00 | 11 |  |  |  |  | 65h |  |
| 15 | 1.3.2.1 | Equipment order |  | 1h | 2017-07-19 08:00 | 2017-07-19 09:00 | 11 | 47.62d |  | start no earlier than 2017-07-19 08:00 | Project Manager | 1h |  |
| 16 | 1.3.2.2 | Equipment delivery |  | 4d | 2017-07-24 08:00 | 2017-07-28 08:00 | 23SF-3d | 25d | 9d | start no earlier than 2017-06-27 08:00 | SLC Warehouse; Fed Ex | 64h |  |
| 17 | 1.3.3 | Installer request sent to scheduling |  | 1h | 2017-07-19 08:00 | 2017-07-19 09:00 | 11 | 47.62d |  | start no earlier than 2017-07-19 08:00 | Project Manager [10%] | 0.1h |  |
| 18 | 1.3.4 | Exchange of Deliverables for Site Readiness |  | 9d | 2017-07-17 08:00 | 2017-07-25 17:00 |  | 40.75d |  | start no earlier than 2017-07-17 08:00 |  |  |  |
| 19 | 1.3.5 | Partial invoicing per Contract Terms | manual | 1h | 2017-07-19 08:00 | 2017-07-19 09:00 | 16SS-14d |  |  |  | Project Manager | 1h |  |
| 20 | 1.3.6 | Site readiness confirmation sent to hotel |  | 1h | 2017-07-19 08:00 | 2017-07-19 09:00 | 23SS-14d | 47.62d |  | start no earlier than 2017-07-19 08:00 | Project Manager | 1h |  |
| 21 | 1.3.7 | Accommodations set up with Hotel |  | 1h | 2017-07-19 08:00 | 2017-07-19 09:00 | 23SS-14d | 47.62d |  | start no earlier than 2017-07-19 08:00 | Project Manager | 1h |  |
| 22 | 1.3.8 | Travel Arrangements Approved |  | 1h | 2017-07-21 08:00 | 2017-07-21 09:00 | 23SS-10d | 45.62d |  | start no earlier than 2017-07-19 08:00 | Project Manager | 1h |  |
| 23 | 1.4 | **Onsite installation** |  | 18d | 2017-07-31 08:00 | 2017-08-17 17:00 |  |  |  |  |  | 218h | 13,520 |
| 24 | 1.4.1 | Installer's arrival | milestone, manual | 0d | 2017-07-30 08:00 | 2017-07-30 08:00 |  |  |  |  | GPNS HSIA installer 1; GPNS HSIA installer 2 |  |  |
| 25 | 1.4.2 | Introductions, site walkthrough |  | 0.5d | 2017-07-31 08:00 | 2017-07-31 12:00 | 24FS+1d | 5.5d |  |  | GPNS HSIA installer 1; GPNS HSIA installer 2 | 8h | 520 |
| 26 | 1.4.3 | Installation preparations, inventory |  | 0.5d | 2017-07-31 08:00 | 2017-07-31 12:00 | 24FS+1d | 10d | 0d |  | GPNS HSIA installer 1; GPNS HSIA installer 2 | 8h | 520 |
| 27 | 1.4.4 | MDF headend installation & configuration |  | 2d | 2017-08-01 08:00 | 2017-08-02 17:00 | 26SS+1d | 10d | 4d |  | GPNS HSIA installer 1 | 16h | 1,040 |
| 28 | 1.4.5 | AP prep work |  | 2d | 2017-08-03 08:00 | 2017-08-04 17:00 | 26SS+1d | 30.75d |  | start no earlier than 2017-08-03 08:00 | GPNS HSIA installer 2 | 16h | 1,040 |
| 29 | 1.4.6 | IDF Switch installations and patching |  | 2d | 2017-08-05 08:00 | 2017-08-06 17:00 | 26FS+1d | 28.75d |  | start no earlier than 2017-08-05 08:00 | GPNS HSIA installer 2 | 16h | 1,040 |
| 30 | 1.4.7 | Cable pull |  | 2d | 2017-08-07 08:00 | 2017-08-08 17:00 | 27 | 6d | 3d | start no earlier than 2017-08-07 08:00 | GPNS HSIA installer 1; GPNS HSIA installer 2 | 32h | 2,080 |
| 31 | 1.4.8 | AP replacement guest, meeting & BOH |  | 4d | 2017-08-09 08:00 | 2017-08-12 17:00 | 30FF+1d | 3d | 1d | start no earlier than 2017-08-09 08:00 | GPNS HSIA installer 1; GPNS HSIA installer 2 | 64h | 4,160 |
| 32 | 1.4.9 | Hotel staff training |  | 8h | 2017-08-14 08:00 | 2017-08-14 17:00 | 31 | 20.75d |  | start no earlier than 2017-08-14 08:00 | GPNS HSIA installer 1 | 8h | 520 |
| 33 | 1.4.10 | OSD and documentation update |  | 2d | 2017-08-15 08:00 | 2017-08-16 17:00 | 31 | 18.75d |  | start no earlier than 2017-08-15 08:00 | GPNS HSIA installer 1 | 16h | 1,040 |
| 34 | 1.4.11 | Air Magnet testing of property |  | 2d | 2017-08-17 08:00 | 2017-08-18 17:00 | 31 | 16.75d |  | start no earlier than 2017-08-17 08:00 | GPNS HSIA installer 2 | 16h | 1,040 |
| 35 | 1.4.12 | Acceptance testing & sign-off |  | 1d | 2017-08-21 08:00 | 2017-08-21 17:00 | 31FS+1d | -4d | 0d | start no earlier than 2017-08-21 08:00 | Hotel Staff [25%]; GPNS HSIA installer 1; Signoff Specialist | 18h | 520 |
| 36 | 1.4.13 | Installers departure | milestone | 0d | 2017-08-21 17:00 | 2017-08-21 17:00 | 35 | -16d | 0d |  | GPNS HSIA installer 1; GPNS HSIA installer 2 |  |  |

| ID | WBS | Task | Duration | Start | Finish | Predecessors | Total slack | Constraint | Resources | Work |
| --- | --- | --- | --- | --- | --- | --- | --- | --- | --- | --- |
| 37 | 2 | **Post Installation** | 0.25d | 2017-08-24 08:00 | 2017-08-24 10:00 | 36FS+2d | 11.5d |  |  | 7h |
| 38 | 2.1 | Project Closing and invoicing | 2h | 2017-08-24 08:00 | 2017-08-24 10:00 | 36FS+1d | 11.5d |  | Project Manager | 2h |
| 39 | 2.2 | Hotel Documents FTP Folder Updated | 2h | 2017-08-24 08:00 | 2017-08-24 10:00 | 36FS+1d | 11.5d |  | Project Manager | 2h |
| 40 | 2.3 | Client Relations Notification email | 1h | 2017-08-24 08:00 | 2017-08-24 09:00 | 36FS+1d | 11.62d |  | Project Manager; Client Relations Manager; Hotel Staff | 3h |
| 41 | 3 | Project complete | 1d | 2017-08-25 08:00 | 2017-08-25 17:00 | 36FS+1d | 9.75d | finish no earlier than 2017-08-25 17:00 |  |  |
